# Proyecto de Ejemplo 1

Schedule from MS Project, 2024-10-01 to 2026-03-24, 6 hours a day.

## Calendars

- Estándar: Mon-Fri 09:00-13:00, 15:00-19:00; Sat-Sun off.
- Calendario L-Mi-V: Mon 08:00-12:00, 13:00-15:00; Tue off; Wed 08:00-12:00, 13:00-15:00; Thu off; Fri 08:00-12:00, 13:00-15:00; Sat-Sun off. Exceptions (off unless hours are given): 2025-01-01 (Año Nuevo), 2025-01-06 (Dia de Reyes), 2025-01-21 (Virgen De La Altagracia), 2025-02-27 (Independencia Nacional), 2025-04-17 (Jueves Santos), 2025-04-18 (Viernes santos), 2025-05-01 (Dia Del Trabajador), 2025-06-19 (Corpus Christi), 2025-09-24 (Dia de La Mercedes), 2025-11-10 (Dia de La Constitucion), 2025-12-24 (Noche Buena), 2025-12-25 (Navidad), 2025-12-31 (Fin de Año), 2026-01-01 (Año Nuevo), 2026-01-06 (Dia de Reyes), 2026-01-21 (Dia de La Altagracia), 2026-01-26 (Juan Pablo Duarte), 2026-02-27 (Independencia).
- Calendario Ma y J: Mon off; Tue 08:00-12:00, 13:00-15:00; Wed off; Thu 08:00-12:00, 13:00-15:00; Fri-Sun off. Exceptions (off unless hours are given): 2025-01-01 (Año Nuevo), 2025-01-06 (Dia de Reyes), 2025-01-21 (Virgen De La Altagracia), 2025-02-27 (Independencia Nacional), 2025-04-17 (Jueves Santos), 2025-04-18 (Viernes Santos), 2025-05-01 (Dia Del Trabajador), 2025-06-19 (Corpus Christi), 2025-08-16 (Dia de la Restauracion), 2025-09-24 (Dia de Las Mercedes), 2025-11-10 (Dia de la Constitucion), 2025-12-24 (Noche Buena), 2025-12-25 (Navidad), 2025-12-31 (Fin de Año), 2026-01-01 (Año Nuevo), 2026-01-06 (Dia de Reyes), 2026-01-21 (Dia de La Altagracia), 2026-01-26 (Dia de Duarte), 2026-02-27 (Independencia).
- Estándar con día feriados: Mon-Fri 09:00-13:00, 15:00-19:00; Sat-Sun off. Exceptions (off unless hours are given): 2025-01-01 (Año Nuevo), 2025-01-06 (Dia de Reyes), 2025-01-21 (Virgen de la Altagracia), 2025-02-27 (Independencia Nacional), 2025-04-17 (Jueves Santos), 2025-04-18 (Viernes Santos), 2025-05-01 (Dia del Trabajador), 2025-06-19 (Corpus Christi), 2025-09-24 (Dia de Las Mercedes), 2025-11-10 (Dia de la Constitucion), 2025-12-24 (Noche Buena), 2025-12-25 (Navidad), 2025-12-31 (Fin de Año), 2026-01-01 (Año Nuevo), 2026-01-06 (Dis de Reyes), 2026-01-21 (Virgen de La Altagracia), 2026-01-26 to 2026-01-27 (Dia de Juan Pablo Duarte), 2026-02-27 (Independencia Nacional).

## Resources

| Resource |
| --- |
| Hoyero 1 |
| Hoyero 2 |
| Hoyero 3 |
| Hoyero 4 |
| Hoyero 5 |
| Hoyero 6 |
| Hoyero 7 |
| Hoyero 8 |
| Hoyero 9 |
| Hoyero 10 |
| Grúa 1 |
| Grúa 2 |
| Grúa 3 |
| Grúa 4 |
| Grúa 5 |
| Grúa 6 |
| Grúa 7 |
| Grúa 8 |
| Grúa 9 |
| Grúa 10 |
| Canasto 1 |
| Canasto 2 |
| Canasto 3 |
| Canasto 4 |
| Canasto 5 |
| Canasto 6 |
| Canasto 7 |
| Canasto 8 |
| Canasto 9 |
| Canasto 10 |
| Brigada de Normalización 1 |
| Brigada de Normalización 2 |
| Brigada de Normalización 3 |
| Brigada de Normalización 4 |
| Brigada de Normalización 5 |
| Brigada de Normalización 6 |
| Brigada de Normalización 7 |
| Brigada de Normalización 8 |
| Brigada de Normalización 9 |
| Brigada de Normalización 10 |
| Supervisor 1 |
| Supervisor 2 |
| Supervisor 3 |
| Supervisor 4 |
| Supervisor 5 |
| Supervisor 6 |
| Supervisor 7 |
| Supervisor 8 |
| Supervisor 9 |
| Supervisor 10 |
| Capataz 1 |
| Capataz 2 |
| Capataz 3 |
| Capataz 4 |
| Capataz 5 |
| Capataz 6 |
| Capataz 7 |
| Capataz 8 |
| Capataz 9 |
| Capataz 10 |
| Brigada de Poda 1 |
| Brigada de Poda 2 |
| Brigada de Poda 3 |
| Brigada de Poda 4 |
| Brigada de Poda 5 |
| Brigada de Poda 6 |
| Brigada de Poda 7 |
| Brigada de Poda 8 |
| Brigada de Poda 9 |
| Brigada de Poda 10 |
| Brigada Ligera 1 |
| Brigada Ligera 2 |
| Brigada Ligera 3 |
| Brigada Ligera 4 |
| Brigada Ligera 5 |
| Brigada Ligera 6 |
| Brigada Ligera 7 |
| Brigada Ligera 8 |
| Brigada Ligera 9 |
| Brigada Ligera 10 |
| Hoyero 1 A |
| Hoyero 2 B |
| Hoyero 3 C |
| Hoyero 4 D |
| Hoyero 5 E |
| Hoyero 6 F |
| Hoyero 7 G |
| Hoyero 8 H |
| Hoyero 9 I |
| Hoyero 10 J |
| Grúa 1 A |
| Grúa 2 B |
| Grúa 3 C |
| Grúa 4 D |
| Grúa 5 E |
| Grúa 6 F |
| Grúa 7 G |
| Grúa 8 H |
| Grúa 9 I |
| Grúa 10 J |
| Canasto 1 A |
| Canasto 2 B |
| Canasto 3 C |
| Canasto 4 D |
| Canasto 5 E |
| Canasto 6 F |
| Canasto 7 G |
| Canasto 8 H |
| Canasto 9 I |
| Canasto 10 J |
| Brigada de Normalización 1 A |
| Brigada de Normalización 2 B |
| Brigada de Normalización 3 C |
| Brigada de Normalización 4 D |
| Brigada de Normalización 5 E |
| Brigada de Normalización 6 F |
| Brigada de Normalización 7 G |
| Brigada de Normalización 8 H |
| Brigada de Normalización 9 I |
| Brigada de Normalización 10 J |
| Supervisor 1 A |
| Supervisor 2 B |
| Supervisor 3 C |
| Supervisor 4 D |
| Supervisor 5 E |
| Supervisor 6 F |
| Supervisor 7 G |
| Supervisor 8 H |
| Supervisor 9 I |
| Supervisor 10 J |
| Capataz 1 A |
| Capataz 2 B |
| Capataz 3 C |
| Capataz 4 D |
| Capataz 5 E |
| Capataz 6 F |
| Capataz 7 G |
| Capataz 8 H |
| Capataz 9 I |
| Capataz 10 J |
| Brigada de Poda 1 A |
| Brigada de Poda 2 B |
| Brigada de Poda 3 C |
| Brigada de Poda 4 D |
| Brigada de Poda 5 E |
| Brigada de Poda 6 F |
| Brigada de Poda 7 G |
| Brigada de Poda 8 H |
| Brigada de Poda 9 I |
| Brigada de Poda 10 J |
| Brigada Ligera 1 A |
| Brigada Ligera 2 B |
| Brigada Ligera 3 C |
| Brigada Ligera 4 D |
| Brigada Ligera 5 E |
| Brigada Ligera 6 F |
| Brigada Ligera 7 G |
| Brigada Ligera 8 H |
| Brigada Ligera 9 I |
| Brigada Ligera 10 J |
| Hoyero 11 |
| Hoyero 12 |
| Hoyero 13 |
| Hoyero 14 |
| Hoyero 15 |
| Hoyero 11 K |
| Hoyero 12 L |
| Hoyero 13 M |
| Hoyero 14 N |
| Hoyero 15 Ñ |
| Canasto 11 |
| Canasto 11 O |
| 6 actividades nuevas |
| 1 chat con mensajes nuevos |
| Canasto 12 P |
| Canasto 12 |

## Schedule

| ID | WBS | Task | Duration | Start | Finish | Predecessors | Total slack | Free slack | Constraint | Calendar | Resources | Work | Días Calendario | Cantidad |
| --- | --- | --- | --- | --- | --- | --- | --- | --- | --- | --- | --- | --- | --- | --- |
| 1 | 1 | **Proyecto LOTE3 (Villa Liberación BONP-101 y Villa Hermosa BPER-102)** | 488.67d | 2024-10-01 | 2026-03-24 |  | 0d |  |  | Estándar con día feriados |  | 15426h | 540días |  |
| 2 | 1.1 | **Preparativos previos Obras** | 44d | 2024-10-01 | 2024-11-14 |  | 2.67d |  |  | Estándar |  |  | 45días |  |
| 3 | 1.1.1 | Reuniones con Contratista | 5d | 2024-10-01 | 2024-10-04 |  | 2.67d | 0d | start no earlier than 2024-10-01 | Estándar |  |  | 4días |  |
| 4 | 1.1.2 | Revisiones adicionales de Ingenieria-Replanteo | 30d | 2024-10-07 | 2024-11-06 | 3FS+1d | 2.67d | 0d |  | Estándar |  |  | 31días |  |
| 5 | 1.1.3 | Firma Minuta | 7d | 2024-11-07 | 2024-11-14 | 4FS+1d | 2.67d | 0d |  | Estándar |  |  | 8días |  |
| 6 | 1.1.4 | Obtension Recursos Contratista | 30d | 2024-10-07 | 2024-11-06 |  | 478.67d |  | start no earlier than 2024-10-07 | Estándar |  |  | 31días |  |
| 7 | 1.1.5 | Gestion de Materiales y Revision contra Fichas Tecnicas | 21d | 2024-10-07 | 2024-10-29 | 3FS+1d | 487d |  |  | Estándar |  |  | 23días |  |
| 8 | 1.2 | **Suministro Materiales** | 119d | 2024-10-17 | 2025-02-19 |  | 379d |  |  | Estándar |  |  | 126días |  |
| 9 | 1.2.1 | Suministro Postes | 90d | 2024-10-17 | 2025-01-20 | 4SS+10d | 379d | 0d |  | Estándar |  |  | 96días |  |
| 10 | 1.2.2 | Suministro Armados | 90d | 2024-10-31 | 2025-02-03 | 9SS+14d | 379d | 0d |  | Estándar |  |  | 96días |  |
| 11 | 1.2.3 | Suministro Tendido (Cables) | 90d | 2024-11-15 | 2025-02-19 | 10SS+15d | 379d | 0d |  | Estándar |  |  | 97días |  |
| 12 | 1.2.4 | Suministro Transformadores | 90d | 2024-11-15 | 2025-02-19 | 11SS | 379d |  |  | Estándar |  |  | 97días |  |
| 13 | 1.2.5 | Suministro Equipos Proteccion | 90d | 2024-11-15 | 2025-02-19 | 11SS | 379d |  |  | Estándar |  |  | 97días |  |
| 14 | 1.2.6 | Suminiostro Alumbrado Publico | 90d | 2024-11-15 | 2025-02-19 | 11SS | 379d |  |  | Estándar |  |  | 97días |  |
| 15 | 1.2.7 | Suministro Acometida y medidores | 90d | 2024-11-15 | 2025-02-19 | 11SS | 379d |  |  | Estándar |  |  | 97días |  |
| 16 | 1.3 | **Ejecucion de Obras** | 468.67d | 2024-11-18 | 2026-03-24 |  | 0d |  |  | Estándar |  | 15426h | 492días |  |
| 17 | 1.3.1 | **Poligono 1** | 54d | 2024-11-18 | 2025-03-26 |  | 91d |  |  |  |  | 1710h | 129días |  |
| 18 | 1.3.1.1 | Excavaciones | 5d | 2024-11-18 | 2024-11-27 | 5FS+1d | 91d | 0d |  |  | Hoyero 1; Hoyero 2; Hoyero 3; Hoyero 4; Hoyero 5; Hoyero 6; Hoyero 7; Hoyero 8; Hoyero 9; Hoyero 10 | 300h | 10días | 219 |
| 19 | 1.3.1.2 | Izado de postes | 5d | 2024-11-18 | 2024-11-27 | 18SS | 147d | 0d |  |  | Grúa 1; Grúa 2; Grúa 3 | 90h | 10días | 106 |
| 20 | 1.3.1.3 | Cimentaciones | 1d | 2025-01-17 | 2025-01-17 | 19FF | 176d |  |  |  | Brigada Ligera 1 | 6h | 1días |  |
| 21 | 1.3.1.4 | Retenidas | 6d | 2024-11-20 | 2024-12-02 | 19SS+1d | 194d |  |  |  | Brigada Ligera 3; Brigada Ligera 4; Canasto 1 | 108h | 13días | 113 |
| 22 | 1.3.1.5 | Armados MT y BT | 5d | 2024-11-20 | 2024-11-29 | 19SS+1d | 147d | 0d |  |  | Canasto 5; Canasto 2; Canasto 3; Canasto 4 | 120h | 10días | 172 |
| 23 | 1.3.1.6 | Tendido de Conductor MT y BT | 6d | 2024-11-25 | 2024-12-06 | 22SS+2d | 147d | 0d |  |  | Canasto 6; Canasto 7; Canasto 8; Canasto 9 | 144h | 12días | 8,695 |
| 24 | 1.3.1.7 | Puesta a Tierra | 4d | 2024-12-02 | 2024-12-09 | 22 | 191d |  |  |  | Canasto 4; Canasto 2; Canasto 3 | 72h | 8días | 119 |
| 25 | 1.3.1.8 | Conexiones y Jumper | 3d | 2024-12-09 | 2024-12-13 | 23 | 147d | 0d |  |  | Canasto 1; Canasto 5; Canasto 6 | 54h | 5días | 84 |
| 26 | 1.3.1.9 | Transformadores | 4d | 2024-12-16 | 2024-12-23 | 25 | 147d | 0d |  |  | Canasto 2; Grúa 1; Grúa 2; Canasto 1; Grúa 3; Canasto 3 | 144h | 8días | 40 |
| 27 | 1.3.1.10 | Alumbrado Público | 3d | 2024-12-20 | 2024-12-25 | 26SS+2d | 184d |  |  |  | Canasto 4; Canasto 5; Canasto 6 | 54h | 6días | 120 |
| 28 | 1.3.1.11 | Etiquetas CT | 1d | 2024-12-25 | 2024-12-25 | 26 | 147d | 0d |  |  | Canasto 1; Canasto 2 | 12h | 1días | 40 |
| 29 | 1.3.1.12 | Totalizadores | 4d | 2024-12-27 | 2025-01-08 | 28 | 147d | 0d |  |  | Canasto 1; Canasto 2; Canasto 3 | 72h | 13días | 40 |
| 30 | 1.3.1.13 | Acometida | 25d | 2025-01-03 | 2025-03-03 | 29SS+2d | 147d | 0d |  |  | Brigada de Normalización 1; Brigada de Normalización 2; Brigada de Normalización 3 | 450h | 60días | 1,496 |
| 31 | 1.3.1.14 | Remoción | 7d | 2025-03-12 | 2025-03-26 | 30FS+3d | 147d |  |  |  | Canasto 1; Grúa 1 | 84h | 15días | 350 |

Notes:
- 19: No se le asigna canasto, pero requiere uno para apertura y cierre de seccionador
- 23: Con una grua es suficiente para darle apoyo a los canastos.

| ID | WBS | Task | Duration | Start | Finish | Predecessors | Total slack | Free slack | Calendar | Resources | Work | Días Calendario | Cantidad |
| --- | --- | --- | --- | --- | --- | --- | --- | --- | --- | --- | --- | --- | --- |
| 33 | 1.3.2 | **Poligono 2** | 57d | 2024-11-21 | 2025-06-24 |  | 0d |  | Calendario Ma y J |  | 2262h | 216días |  |
| 34 | 1.3.2.1 | Excavaciones | 8d | 2024-11-21 | 2024-12-17 | 5FS+1d | 0d |  | Calendario Ma y J | Hoyero 1 A; Hoyero 2 B; Hoyero 3 C; Hoyero 4 D; Hoyero 5 E; Hoyero 6 F; Hoyero 7 G; Hoyero 8 H; Hoyero 9 I; Hoyero 10 J | 480h | 27días | 328 |
| 35 | 1.3.2.2 | Izado de postes | 8d | 2024-11-21 | 2024-12-17 | 34SS | 75d | 0d | Calendario Ma y J | Grúa 1 A; Grúa 2 B; Grúa 3 C | 144h | 27días | 163 |
| 36 | 1.3.2.3 | Cimentaciones | 1d | 2024-12-19 | 2024-12-19 | 35 | 123d |  | Calendario Ma y J | Brigada Ligera 1 A | 6h | 1días |  |
| 37 | 1.3.2.4 | Retenidas | 6d | 2024-12-03 | 2024-12-19 | 35SS+3d | 123d |  | Calendario Ma y J | Brigada Ligera 4 D; Canasto 1 A; Brigada Ligera 2 B; Brigada Ligera 3 C | 144h | 17días | 165 |
| 38 | 1.3.2.5 | Armados MT y BT | 8d | 2024-12-03 | 2024-12-26 | 35SS+3d | 75d | 0d | Calendario Ma y J | Canasto 2 B; Canasto 3 C; Canasto 4 D; Canasto 5 E | 192h | 24días | 270 |
| 39 | 1.3.2.6 | Tendido de Conductor MT y BT | 10d | 2024-12-17 | 2025-01-16 | 38SS+4d | 75d | 0d | Calendario Ma y J | Canasto 6 F; Canasto 7 G; Canasto 8 H; Canasto 9 I; Canasto 10 J | 300h | 31días | 16,813 |
| 40 | 1.3.2.7 | Puesta a Tierra | 6d | 2024-12-31 | 2025-01-16 | 38 | 115d |  | Calendario Ma y J | Canasto 1 A; Canasto 2 B; Canasto 3 C | 108h | 17días | 167 |
| 41 | 1.3.2.8 | Conexiones y Jumper | 6d | 2025-01-14 | 2025-02-04 | 39SS+8d | 75d | 0d | Calendario Ma y J | Canasto 4 D; Canasto 5 E | 72h | 22días | 117 |
| 42 | 1.3.2.9 | Transformadores | 5d | 2025-02-06 | 2025-02-20 | 41 | 75d | 0d | Calendario Ma y J | Canasto 4 D; Grúa 1 A; Grúa 2 B; Grúa 3 C; Grúa 4 D; Canasto 1 A; Canasto 2 B; Canasto 3 C | 240h | 15días | 61 |
| 43 | 1.3.2.10 | Alumbrado Público | 4d | 2025-02-13 | 2025-02-25 | 42SS+2d | 105d |  | Calendario Ma y J | Canasto 5 E; Canasto 6 F; Canasto 7 G; Canasto 8 H | 96h | 13días | 198 |
| 44 | 1.3.2.11 | Etiquetas CT | 2d | 2025-02-20 | 2025-02-25 | 42SS+4d | 75d | 0d | Calendario Ma y J | Canasto 9 I; Canasto 10 J | 24h | 6días | 69 |
| 45 | 1.3.2.12 | Totalizadores | 8d | 2025-03-04 | 2025-03-27 | 44 | 75d | 0d | Calendario Ma y J | Canasto 1 A; Canasto 2 B; Canasto 3 C | 144h | 24días | 69 |
| 46 | 1.3.2.13 | Acometida | 18d | 2025-03-06 | 2025-05-13 | 45SS+1d | 75d | 0d | Calendario Ma y J | Brigada de Normalización 1 A; Brigada de Normalización 2 B | 216h | 69días | 718 |
| 47 | 1.3.2.14 | Remoción | 8d | 2025-05-27 | 2025-06-24 | 46FS+3d | 75d |  | Calendario Ma y J | Canasto 1 A; Grúa 1 A | 96h | 29días | 410 |
| 49 | 1.3.3 | **Poligono 3** | 67d | 2024-12-02 | 2025-05-12 |  | 91d |  |  |  | 2304h | 162días |  |
| 50 | 1.3.3.1 | Excavaciones | 9d | 2024-12-02 | 2024-12-20 | 18FS+1d | 91d | 0d |  | Hoyero 3; Hoyero 4; Hoyero 5; Hoyero 6; Hoyero 7; Hoyero 8; Hoyero 9; Hoyero 10; Hoyero 1; Hoyero 2 | 540h | 19días | 373 |
| 51 | 1.3.3.2 | Izado de postes | 13d | 2024-12-02 | 2024-12-30 | 50SS | 128d | 0d |  | Grúa 4; Grúa 5 | 156h | 29días | 181 |
| 52 | 1.3.3.3 | Cimentaciones | 1d | 2025-02-19 | 2025-02-19 | 51FF | 162d |  |  | Brigada Ligera 1 | 6h | 1días |  |
| 53 | 1.3.3.4 | Retenidas | 6d | 2024-12-20 | 2025-01-03 | 51SS+8d | 128d | 0d |  | Brigada Ligera 3; Brigada Ligera 4; Canasto 10; Brigada Ligera 5 | 144h | 15días | 192 |
| 54 | 1.3.3.5 | Armados MT y BT | 8d | 2025-01-08 | 2025-01-24 | 53 | 128d | 0d |  | Canasto 7; Canasto 8; Canasto 10; Canasto 9 | 192h | 17días | 245 |
| 55 | 1.3.3.6 | Tendido de Conductor MT y BT | 15d | 2025-01-10 | 2025-02-12 | 54SS+1d | 128d | 0d |  | Canasto 4; Canasto 5; Canasto 6 | 270h | 34días | 16,123 |
| 56 | 1.3.3.7 | Puesta a Tierra | 6d | 2025-01-27 | 2025-02-07 | 54 | 167d |  |  | Canasto 1; Canasto 2; Canasto 3 | 108h | 12días | 168 |
| 57 | 1.3.3.8 | Conexiones y Jumper | 6d | 2025-02-14 | 2025-02-26 | 55 | 128d | 0d |  | Canasto 5; Canasto 6; Canasto 4 | 108h | 13días | 167 |
| 58 | 1.3.3.9 | Transformadores | 6d | 2025-02-28 | 2025-03-12 | 57 | 128d | 0d |  | Grúa 3; Canasto 3; Canasto 4; Canasto 5; Grúa 4; Grúa 5 | 216h | 13días | 53 |
| 59 | 1.3.3.10 | Alumbrado Público | 4d | 2025-03-07 | 2025-03-14 | 58SS+3d | 152d |  |  | Canasto 7; Canasto 6; Canasto 8 | 72h | 8días | 195 |
| 60 | 1.3.3.11 | Etiquetas CT | 2d | 2025-03-10 | 2025-03-12 | 58SS+4d | 153d |  |  | Canasto 9; Canasto 10 | 24h | 3días | 58 |
| 61 | 1.3.3.12 | Totalizadores | 6d | 2025-03-14 | 2025-03-26 | 58 | 128d | 0d |  | Canasto 3; Canasto 4; Canasto 5 | 108h | 13días | 58 |
| 62 | 1.3.3.13 | Acometida | 21d | 2025-03-21 | 2025-05-09 | 61SS+3d | 128d | 0d |  | Brigada de Normalización 1; Brigada de Normalización 2 | 252h | 50días | 821 |
| 63 | 1.3.3.14 | Remoción | 9d | 2025-04-23 | 2025-05-12 | 62SS+13d | 128d |  |  | Canasto 1; Grúa 1 | 108h | 20días | 460 |

Notes:
- 35: No se le asigna canasto, pero requiere uno para apertura y cierre de seccionador
- 39: Con una grua es suficiente para darle apoyo a los canastos.
- 51: No se le asigna canasto, pero requiere uno para apertura y cierre de seccionador
- 55: Con una grua es suficiente para darle apoyo a los canastos.

| ID | WBS | Task | Duration | Start | Finish | Predecessors | Total slack | Free slack | Calendar | Resources | Work | Días Calendario | Cantidad |
| --- | --- | --- | --- | --- | --- | --- | --- | --- | --- | --- | --- | --- | --- |
| 65 | 1.3.4 | **Poligono 4** | 67d | 2024-12-19 | 2025-08-26 |  | 0d |  | Calendario Ma y J |  | 2028h | 251días |  |
| 66 | 1.3.4.1 | Excavaciones | 8d | 2024-12-19 | 2025-01-14 | 34 | 0d |  | Calendario Ma y J | Hoyero 1 A; Hoyero 2 B; Hoyero 3 C; Hoyero 4 D; Hoyero 5 E; Hoyero 6 F; Hoyero 7 G; Hoyero 8 H; Hoyero 9 I; Hoyero 10 J | 480h | 27días | 311 |
| 67 | 1.3.4.2 | Izado de postes | 8d | 2024-12-19 | 2025-01-14 | 66SS | 0d |  | Calendario Ma y J | Grúa 1 A; Grúa 2 B; Grúa 3 C | 144h | 27días | 166 |
| 68 | 1.3.4.3 | Cimentaciones | 1d | 2025-01-16 | 2025-01-16 | 67 | 115d |  | Calendario Ma y J | Brigada Ligera 1 A | 6h | 1días |  |
| 69 | 1.3.4.4 | Retenidas | 4d | 2025-01-07 | 2025-01-16 | 67SS+5d | 115d |  | Calendario Ma y J | Brigada Ligera 4 D; Brigada Ligera 5 E; Brigada Ligera 2 B; Brigada Ligera 3 C; Canasto 11 O | 120h | 10días | 145 |
| 70 | 1.3.4.5 | Armados MT y BT | 8d | 2025-03-04 | 2025-03-27 | 67FS+11d | 0d |  | Calendario Ma y J | Canasto 4 D; Canasto 5 E; Canasto 6 F | 144h | 24días | 192 |
| 71 | 1.3.4.6 | Tendido de Conductor MT y BT | 10d | 2025-03-18 | 2025-04-22 | 70SS+4d | 0d |  | Calendario Ma y J | Canasto 7 G; Canasto 8 H; Canasto 9 I; Canasto 10 J | 240h | 36días | 14,010 |
| 72 | 1.3.4.7 | Puesta a Tierra | 5d | 2025-04-03 | 2025-04-22 | 71SS+5d | 91d |  | Calendario Ma y J | Canasto 5 E; Canasto 6 F | 60h | 20días | 109 |
| 73 | 1.3.4.8 | Conexiones y Jumper | 4d | 2025-04-15 | 2025-04-29 | 71SS+8d | 0d |  | Calendario Ma y J | Canasto 3 C; Canasto 1 A; Canasto 2 B | 72h | 15días | 116 |
| 74 | 1.3.4.9 | Transformadores | 2d | 2025-04-29 | 2025-05-06 | 73SS+3d | 0d |  | Calendario Ma y J | Grúa 3 C; Grúa 1 A; Grúa 2 B; Canasto 4 D; Canasto 5 E; Canasto 6 F | 72h | 8días | 21 |
| 75 | 1.3.4.10 | Alumbrado Público | 4d | 2025-05-08 | 2025-05-20 | 74 | 84d |  | Calendario Ma y J | Canasto 3 C; Canasto 4 D; Canasto 2 B | 72h | 13días | 173 |
| 76 | 1.3.4.11 | Etiquetas CT | 1d | 2025-05-08 | 2025-05-08 | 74 | 57d | 0d | Calendario Ma y J | Canasto 5 E | 6h | 1días | 21 |
| 77 | 1.3.4.12 | Totalizadores | 4d | 2025-05-13 | 2025-05-22 | 76 | 57d | 0d | Calendario Ma y J | Canasto 6 F; Canasto 5 E | 48h | 10días | 21 |
| 78 | 1.3.4.13 | Acometida | 26d | 2025-05-20 | 2025-08-19 | 77SS+2d | 57d | 0d | Calendario Ma y J | Brigada de Normalización 1 A; Brigada de Normalización 2 B; Brigada de Normalización 3 C | 468h | 92días | 1,557 |
| 79 | 1.3.4.14 | Remoción | 8d | 2025-07-31 | 2025-08-26 | 78SS+20d | 57d |  | Calendario Ma y J | Canasto 1 A; Grúa 1 A | 96h | 27días | 415 |
| 81 | 1.3.5 | **Poligono 5** | 62d | 2025-03-14 | 2025-08-06 |  | 91d |  |  |  | 1752h | 146días |  |
| 82 | 1.3.5.1 | Excavaciones | 8d | 2025-03-14 | 2025-03-31 | 50FS+33d | 91d | 0d |  | Hoyero 4; Hoyero 5; Hoyero 6; Hoyero 7; Hoyero 8; Hoyero 9; Hoyero 10; Hoyero 1; Hoyero 2; Hoyero 3 | 480h | 18días | 338 |
| 83 | 1.3.5.2 | Izado de postes | 6d | 2025-03-14 | 2025-03-26 | 82SS | 91d | 0d |  | Grúa 4; Grúa 2; Grúa 5; Grúa 3 | 144h | 13días | 172 |
| 84 | 1.3.5.3 | Cimentaciones | 1d | 2025-03-26 | 2025-03-26 | 83FF | 147d |  |  | Brigada Ligera 1 | 6h | 1días |  |
| 85 | 1.3.5.4 | Retenidas | 6d | 2025-03-21 | 2025-04-02 | 83SS+3d | 144d |  |  | Brigada Ligera 4; Brigada Ligera 3; Brigada Ligera 2; Canasto 6 | 144h | 13días | 166 |
| 86 | 1.3.5.5 | Armados MT y BT | 10d | 2025-03-28 | 2025-04-21 | 83SS+6d | 91d | 0d |  | Canasto 3; Canasto 4; Canasto 5; Canasto 2 | 240h | 25días | 305 |
| 87 | 1.3.5.6 | Tendido de Conductor MT y BT | 8d | 2025-04-23 | 2025-05-09 | 86 | 91d | 0d |  | Canasto 3; Canasto 4; Canasto 5; Canasto 2 | 192h | 17días | 11,577 |
| 88 | 1.3.5.7 | Puesta a Tierra | 4d | 2025-05-12 | 2025-05-19 | 87 | 91d | 0d |  | Canasto 3; Canasto 4; Canasto 2 | 72h | 8días | 107 |
| 89 | 1.3.5.8 | Conexiones y Jumper | 2d | 2025-05-21 | 2025-05-23 | 88 | 91d | 0d |  | Canasto 3; Canasto 4; Canasto 2 | 36h | 3días | 70 |
| 90 | 1.3.5.9 | Transformadores | 2d | 2025-05-26 | 2025-05-28 | 89 | 91d | 0d |  | Canasto 4; Canasto 5; Grúa 3; Grúa 4; Grúa 5; Canasto 3 | 72h | 3días | 22 |
| 91 | 1.3.5.10 | Alumbrado Público | 4d | 2025-05-30 | 2025-06-06 | 90 | 91d | 0d |  | Canasto 4; Canasto 5; Canasto 3 | 72h | 8días | 176 |
| 92 | 1.3.5.11 | Etiquetas CT | 1d | 2025-06-09 | 2025-06-09 | 91 | 91d | 0d |  | Canasto 3 | 6h | 1días | 22 |
| 93 | 1.3.5.12 | Totalizadores | 4d | 2025-06-11 | 2025-06-18 | 92 | 91d | 0d |  | Canasto 4; Canasto 3 | 48h | 8días | 22 |
| 94 | 1.3.5.13 | Acometida | 13d | 2025-06-23 | 2025-07-21 | 93FS+1d | 91d | 0d |  | Brigada de Normalización 2; Brigada de Normalización 1 | 156h | 29días | 522 |
| 95 | 1.3.5.14 | Remoción | 7d | 2025-07-23 | 2025-08-06 | 94 | 91d |  |  | Grúa 1; Canasto 1 | 84h | 15días | 345 |

Notes:
- 67: No se le asigna canasto, pero requiere uno para apertura y cierre de seccionador
- 71: Con una grua es suficiente para darle apoyo a los canastos.
- 83: No se le asigna canasto, pero requiere uno para apertura y cierre de seccionador
- 87: Con una grua es suficiente para darle apoyo a los canastos.

| ID | WBS | Task | Duration | Start | Finish | Predecessors | Total slack | Calendar | Resources | Work | Días Calendario | Cantidad |
| --- | --- | --- | --- | --- | --- | --- | --- | --- | --- | --- | --- | --- |
| 97 | 1.3.6 | **Poligono 6** | 88d | 2025-05-08 | 2026-03-24 |  | 0d | Calendario Ma y J |  | 5370h | 321días |  |
| 98 | 1.3.6.1 | Excavaciones | 16d | 2025-05-08 | 2025-07-03 | 74 | 0d | Calendario Ma y J | Hoyero 3 C; Hoyero 4 D; Hoyero 5 E; Hoyero 6 F; Hoyero 7 G; Hoyero 8 H; Hoyero 9 I; Hoyero 10 J; Hoyero 11 K; Hoyero 12 L; Hoyero 13 M; Hoyero 14 N; Hoyero 15 Ñ; Hoyero 1 A; Hoyero 2 B | 1440h | 57días | 977 |
| 99 | 1.3.6.2 | Izado de postes | 18d | 2025-05-08 | 2025-07-10 | 98SS | 0d | Calendario Ma y J | Grúa 4 D; Grúa 5 E; Grúa 2 B; Grúa 3 C | 432h | 64días | 498 |
| 100 | 1.3.6.3 | Cimentaciones | 3d | 2025-07-03 | 2025-07-10 | 99FF | 70d | Calendario Ma y J | Brigada Ligera 1 A | 18h | 8días | 14 |
| 101 | 1.3.6.4 | Retenidas | 10d | 2025-06-26 | 2025-07-29 | 99SS+13d | 65d | Calendario Ma y J | Brigada Ligera 2 B; Brigada Ligera 3 C; Brigada Ligera 4 D; Canasto 2 B; Brigada Ligera 5 E; Brigada Ligera 6 F; Canasto 4 D | 420h | 34días | 479 |
| 102 | 1.3.6.5 | Armados MT y BT | 15d | 2025-06-10 | 2025-07-31 | 99SS+9d | 0d | Calendario Ma y J | Canasto 5 E; Canasto 6 F; Canasto 3 C; Canasto 7 G; Canasto 8 H; Canasto 9 I; Canasto 10 J | 630h | 52días | 851 |
| 103 | 1.3.6.6 | Tendido de Conductor MT y BT | 11d | 2025-08-05 | 2025-09-09 | 102 | 0d | Calendario Ma y J | Canasto 4 D; Canasto 5 E; Canasto 2 B; Canasto 8 H; Canasto 9 I; Canasto 10 J; Canasto 6 F; Canasto 7 G | 528h | 36días | 31,161 |
| 104 | 1.3.6.7 | Puesta a Tierra | 6d | 2025-09-11 | 2025-09-30 | 103 | 0d | Calendario Ma y J | Canasto 3 C; Canasto 4 D; Canasto 5 E; Canasto 2 B; Canasto 6 F; Canasto 7 G | 216h | 20días | 386 |
| 105 | 1.3.6.8 | Conexiones y Jumper | 9d | 2025-09-11 | 2025-10-09 | 103 | 44d | Calendario Ma y J | Canasto 8 H; Canasto 9 I; Canasto 10 J | 162h | 29días | 272 |
| 106 | 1.3.6.9 | Transformadores | 5d | 2025-10-02 | 2025-10-16 | 104 | 0d | Calendario Ma y J | Grúa 3 C; Grúa 4 D; Canasto 2 B; Canasto 3 C; Canasto 4 D; Grúa 5 E; Grúa 2 B; Grúa 1 A; Canasto 1 A; Canasto 5 E | 300h | 15días | 61 |
| 107 | 1.3.6.10 | Alumbrado Público | 5d | 2025-10-21 | 2025-11-04 | 106 | 0d | Calendario Ma y J | Canasto 2 B; Canasto 3 C; Canasto 4 D; Canasto 5 E; Canasto 1 A; Canasto 6 F; Canasto 7 G; Canasto 8 H | 240h | 15días | 510 |
| 108 | 1.3.6.11 | Etiquetas CT | 2d | 2025-10-21 | 2025-10-23 | 106 | 40d | Calendario Ma y J | Canasto 9 I; Canasto 10 J | 24h | 3días | 63 |
| 109 | 1.3.6.12 | Totalizadores | 3d | 2025-11-06 | 2025-11-13 | 107 | 0d | Calendario Ma y J | Canasto 3 C; Canasto 4 D; Canasto 2 B; Canasto 1 A; Canasto 5 E; Canasto 6 F; Canasto 7 G | 126h | 8días | 63 |
| 110 | 1.3.6.13 | Acometida | 29d | 2025-11-11 | 2026-02-26 | 109SS+1d | 0d | Calendario Ma y J | Brigada de Normalización 1 A; Brigada de Normalización 2 B; Brigada de Normalización 3 C | 522h | 108días | 1,720 |
| 111 | 1.3.6.14 | Remoción | 13d | 2026-02-10 | 2026-03-24 | 110SS+23d | 0d | Calendario Ma y J | Grúa 2 B; Canasto 1 A; Grúa 1 A; Canasto 2 B | 312h | 43días | 1,245 |

Notes:
- 99: No se le asigna canasto, pero requiere uno para apertura y cierre de seccionador
- 103: Con una grua es suficiente para darle apoyo a los canastos.
